# 1749_50_51_52_53_programma

Schedule from MS Project, 2013-01-01 to 2014-06-29.
Studio Michaelides Associati

## Calendars

- Standard: Mon-Sun 08:00-12:00, 13:00-17:00.

## Schedule

| ID | WBS | Task | Duration | Start | Finish | Predecessors | Total slack | Free slack |
| --- | --- | --- | --- | --- | --- | --- | --- | --- |
| 1 | 1 | **POR FESR 07/13 - III.2.2 - P.I.S.U. "Ex Ospedale S. Andrea"** | 545d | 2013-01-01 | 2014-06-29 |  | 0d |  |
| 2 | 1.1 | **EX PADIGLIONE 18 E PIAZZA LOTTO 1** | 480d | 2013-01-01 | 2014-04-25 |  | 65d |  |
| 3 | 1.1.1 | Progetto Esecutivo | 60d | 2013-01-01 | 2013-03-01 |  | 65d | 0d |
| 4 | 1.1.2 | Approvazione Esecuivo | 30d | 2013-03-02 | 2013-03-31 | 3 | 65d | 0d |
| 5 | 1.1.3 | Esecuzione Lavori | 390d | 2013-04-01 | 2014-04-25 | 4 | 65d |  |
| 6 | 1.2 | **BIBLIOTECA** | 450d | 2013-01-01 | 2014-03-26 |  | 95d |  |
| 7 | 1.2.1 | Progetto Esecutivo | 60d | 2013-01-01 | 2013-03-01 |  | 95d | 0d |
| 8 | 1.2.2 | Approvazione Esecutivo | 30d | 2013-03-02 | 2013-03-31 | 7 | 95d | 0d |
| 9 | 1.2.3 | Esecuzione Lavori | 360d | 2013-04-01 | 2014-03-26 | 8 | 95d |  |
| 10 | 1.3 | **EX MONASTERO SAN PIETRO MARTIRE** | 545d | 2013-01-01 | 2014-06-29 |  | 0d |  |
| 11 | 1.3.1 | Progetto Esecutivo | 45d | 2013-01-01 | 2013-02-14 |  | 0d |  |
| 12 | 1.3.2 | Approvazione Esecutivo | 30d | 2013-02-15 | 2013-03-16 | 11 | 0d |  |
| 13 | 1.3.3 | Esecuzione lavori | 470d | 2013-03-17 | 2014-06-29 | 12 | 0d |  |
