# 1753_cronoprogramma

Schedule from MS Project, 2013-01-01 to 2014-03-26.
Studio Michaelides Associati

## Calendars

- Standard: Mon-Sun 08:00-12:00, 13:00-17:00.

## Schedule

| ID | WBS | Task | Duration | Start | Finish | Predecessors | Total slack | Free slack |
| --- | --- | --- | --- | --- | --- | --- | --- | --- |
| 1 | 1 | **Biblioteca** | 450d | 2013-01-01 | 2014-03-26 |  | 0d |  |
| 2 | 1.1 | Progetto Esecutivo | 60d | 2013-01-01 | 2013-03-01 |  | 0d |  |
| 3 | 1.2 | Approvazione Progetto Esecuivo | 30d | 2013-03-02 | 2013-03-31 | 2 | 0d |  |
| 4 | 1.3 | **Esecuzione Lavori** | 360d | 2013-04-01 | 2014-03-26 | 3 | 0d |  |
| 5 | 1.3.1 | **Allestimento Cantiere** | 15d | 2013-04-01 | 2013-04-15 |  | 0d |  |
| 6 | 1.3.1.1 | Posa recinzione di cantiere e segnaletica di sicurezza | 8d | 2013-04-01 | 2013-04-08 |  | 0d |  |
| 7 | 1.3.1.2 | Formazione servizi logistici ed igienico assistenziali | 3d | 2013-04-09 | 2013-04-11 | 6 | 0d |  |
| 8 | 1.3.1.3 | Formazione impianto elettrico di cantiere | 2d | 2013-04-12 | 2013-04-13 | 7 | 363d | 0d |
| 9 | 1.3.1.4 | Installazione gru di cantiere | 2d | 2013-04-14 | 2013-04-15 | 8 | 363d |  |
| 10 | 1.3.2 | **Opere Edili** | 332d | 2013-04-09 | 2014-03-06 |  | 0d |  |
| 11 | 1.3.2.1 | Ponteggi | 10d | 2013-04-09 | 2013-04-18 | 7SS | 0d |  |
| 12 | 1.3.2.2 | Rimozioni e demolizioni | 42d | 2013-04-19 | 2013-05-30 | 11 | 0d |  |
| 13 | 1.3.2.3 | Scavo + vespaio | 42d | 2013-05-17 | 2013-06-27 | 12FS-14d | 0d |  |
| 14 | 1.3.2.4 | Consolidamento murature | 42d | 2013-06-14 | 2013-07-25 | 13FS-14d | 0d |  |
| 15 | 1.3.2.5 | Consolidamento volte | 56d | 2013-07-26 | 2013-09-19 | 14 | 0d |  |
| 16 | 1.3.2.6 | Massetti | 28d | 2013-09-20 | 2013-10-17 | 15 | 0d |  |
| 17 | 1.3.2.7 | Nuove murature | 14d | 2013-10-18 | 2013-10-31 | 16 | 0d |  |
| 18 | 1.3.2.8 | Intonaci - Restauri fronti | 196d | 2013-08-23 | 2014-03-06 | 15FS-28d | 20d |  |
| 19 | 1.3.2.9 | Serramenti esterni | 28d | 2013-11-15 | 2013-12-12 | 17FS+14d | 0d |  |
| 20 | 1.3.2.10 | Sottofondi | 28d | 2013-11-29 | 2013-12-26 | 19FS-14d | 0d |  |
| 21 | 1.3.2.11 | Pavimenti e rivestimenti | 28d | 2013-12-27 | 2014-01-23 | 20 | 0d |  |
| 22 | 1.3.2.12 | Finiture interne | 56d | 2014-01-10 | 2014-03-06 | 21FS-14d | 0d |  |
| 23 | 1.3.3 | **Impianti** | 141d | 2013-10-25 | 2014-03-14 |  | 12d |  |
| 24 | 1.3.3.1 | Impianti meccanici: riscaldamento, idrico sanitario, antincendio | 84d | 2013-10-25 | 2014-02-13 | 16FS+7d | 12d | 0d |
| 25 | 1.3.3.2 | Impianti elettrici | 70d | 2013-11-22 | 2014-02-28 | 24SS+28d | 12d | 0d |
| 26 | 1.3.3.3 | Impianto ascensore | 28d | 2014-02-15 | 2014-03-14 | 25FS-14d | 12d | 0d |

| ID | WBS | Task | Duration | Start | Finish | Predecessors | Total slack | Free slack |
| --- | --- | --- | --- | --- | --- | --- | --- | --- |
| 27 | 1.3.4 | **Locali tecnici interrati** | 112d | 2013-05-17 | 2013-09-05 |  | 202d |  |
| 28 | 1.3.4.1 | Scavi | 42d | 2013-05-17 | 2013-06-27 | 13SS | 202d | 0d |
| 29 | 1.3.4.2 | Strutture in c.a. | 70d | 2013-06-14 | 2013-08-22 | 28FS-14d | 202d | 0d |
| 30 | 1.3.4.3 | Opere di finitura | 14d | 2013-08-23 | 2013-09-05 | 29 | 202d |  |
| 31 | 1.3.5 | **Ripristino Coperture** | 198d | 2013-04-09 | 2013-10-23 |  | 112d |  |
| 32 | 1.3.5.1 | Attività preparatorie | 15d | 2013-04-09 | 2013-04-23 | 6 | 112d | 0d |
| 33 | 1.3.5.2 | Rimozioni e demolizioni | 15d | 2013-04-24 | 2013-05-08 | 32 | 112d | 0d |
| 34 | 1.3.5.3 | Rirpistino strutture di coperture | 140d | 2013-05-09 | 2013-09-25 | 33 | 112d | 0d |
| 35 | 1.3.5.4 | Manto di copertura in coppi | 42d | 2013-09-12 | 2013-10-23 | 34FS-14d | 112d | 0d |
| 36 | 1.3.6 | **Opere Esterne** | 128d | 2013-10-24 | 2014-02-28 |  | 26d |  |
| 37 | 1.3.6.1 | Fognature esterne | 14d | 2014-02-15 | 2014-02-28 | 26SS | 26d |  |
| 38 | 1.3.6.2 | Pavimentazioni | 60d | 2013-10-24 | 2013-12-22 | 35 | 112d | 0d |
| 39 | 1.3.6.3 | Sistemazioni esterne | 14d | 2013-12-09 | 2013-12-22 | 38FF | 112d |  |
| 40 | 1.3.7 | **Smobilizzo Cantiere** | 20d | 2014-03-07 | 2014-03-26 |  | 0d |  |
| 41 | 1.3.7.1 | Rimozione gru di cantiere | 2d | 2014-03-07 | 2014-03-08 | 22 | 0d |  |
| 42 | 1.3.7.2 | Rimozione servizi logistici ed igienico assistenziali | 10d | 2014-03-09 | 2014-03-18 | 41 | 0d |  |
| 43 | 1.3.7.3 | Rimozione impianto elettrico di cantiere | 3d | 2014-03-19 | 2014-03-21 | 42 | 0d |  |
| 44 | 1.3.7.4 | Rimozione recinzione di cantiere e segnaletica di sicurezza | 5d | 2014-03-22 | 2014-03-26 | 43 | 0d |  |
